# Projectplan

Schedule from MS Project, 2024-01-08 to 2024-04-30, A marks actual dates.

## Calendars

- Standard: Mon-Fri 08:00-12:00, 13:00-17:00; Sat-Sun off.

## Resources

| Resource |
| --- |
| Kevin |
| Peter |
| Vegard |
| Joar |

## Schedule

| ID | WBS | Task | Type | Duration | Start | Finish | Predecessors | Complete | Remaining | Total slack | Constraint | Resources | Work | Actual work |
| --- | --- | --- | --- | --- | --- | --- | --- | --- | --- | --- | --- | --- | --- | --- |
| 1 | 1 | **Oppstartsfase** |  | 14d | 2024-01-08 A | 2024-01-25 A |  | 100% |  |  |  |  | 84h | 84h |
| 2 | 1.1 | **Administrativt** |  | 7d | 2024-01-08 A | 2024-01-16 A |  | 100% |  |  |  |  | 44h | 44h |
| 3 | 1.1.1 | **Prosjektplan** |  | 7d | 2024-01-08 A | 2024-01-16 A |  | 100% |  |  |  |  | 16h | 16h |
| 4 | 1.1.1.1 | Opprette Prosjektplan Microsoft Project | manual | 7d | 2024-01-08 A | 2024-01-16 A |  | 100% |  |  | start no earlier than 2024-01-08 | Kevin | 16h | 16h |
| 5 | 1.1.2 | **Mal timeføring** |  | 5d | 2024-01-08 A | 2024-01-12 A |  | 100% |  |  |  |  | 4h | 4h |
| 6 | 1.1.2.1 | Makroaktivert Excelark for timeføring | manual | 5d | 2024-01-08 A | 2024-01-12 A |  | 100% |  |  |  | Kevin | 4h | 4h |
| 7 | 1.1.3 | **Tilgjenglighet utstyr** |  | 1d | 2024-01-15 A | 2024-01-15 A |  | 100% |  |  |  |  | 24h | 24h |
| 8 | 1.1.3.1 | Finne tilgjengelig utstyr på NTNU | manual | 1d | 2024-01-15 A | 2024-01-15 A |  | 100% |  |  |  | Joar; Kevin; Peter; Vegard | 24h | 24h |
| 9 | 1.2 | **Befaring** |  | 8d | 2024-01-16 A | 2024-01-25 A |  | 100% |  |  |  |  | 40h | 40h |
| 10 | 1.2.1 | Forberedelse | manual | 7d | 2024-01-16 A | 2024-01-24 A |  | 100% |  |  | start no earlier than 2024-01-16 | Joar; Kevin; Peter; Vegard | 18h | 18h |
| 11 | 1.2.2 | Urban Gartneren AS | manual | 1d | 2024-01-25 A | 2024-01-25 A | 10 | 100% |  |  |  | Joar; Kevin; Peter; Vegard | 22h | 22h |
| 12 | 2 | Oppstartsfase fullført | milestone | 0d | 2024-01-25 | 2024-01-25 | 1 |  |  | 0d |  |  |  |  |
| 13 | 3 | **Prosjekteringsfase** |  | 26d | 2024-01-26 A | 2024-03-01 | 12 | 45% | 14.37d | 0d |  |  | 346h | 123h |
| 14 | 3.1 | **Administrativt** |  | 4d | 2024-02-12 A | 2024-02-15 A |  | 100% |  |  |  |  | 8h | 8h |
| 15 | 3.1.1 | **Budsjett** |  | 2d | 2024-02-12 A | 2024-02-13 A |  | 100% |  |  |  |  | 4h | 4h |
| 16 | 3.1.1.1 | Lage budsjett | manual | 2d | 2024-02-12 A | 2024-02-13 A |  | 100% |  |  |  | Kevin | 4h | 4h |
| 17 | 3.1.2 | **Innkjøp** |  | 2d | 2024-02-14 A | 2024-02-15 A |  | 100% |  |  |  |  | 4h | 4h |
| 18 | 3.1.2.1 | Sende bestillinger | manual | 2d | 2024-02-14 A | 2024-02-15 A | 16 | 100% |  |  |  | Kevin | 4h | 4h |
| 19 | 3.2 | **Bygg** |  | 11d | 2024-01-26 A | 2024-02-09 |  | 9% | 10d | 0d |  |  | 32h | 6h |
| 20 | 3.2.1 | **Prosjektering** |  | 6d | 2024-01-26 | 2024-02-02 |  |  |  | 0d |  |  | 14h |  |
| 21 | 3.2.1.1 | 3D-modell | manual | 6d | 2024-01-26 | 2024-02-02 |  |  |  |  |  | Peter | 14h |  |
| 22 | 3.2.2 | **Dokumetnasjon** |  | 5d | 2024-02-05 A | 2024-02-09 | 20 | 20% | 4d | 0d |  |  | 18h | 6h |
| 23 | 3.2.2.1 | Finne frem nødvendig datablad | manual | 2d | 2024-02-05 | 2024-02-06 | 21 |  |  |  |  | Kevin | 6h |  |
| 24 | 3.2.2.2 | Oppdatere rapport | manual | 2d | 2024-02-07 | 2024-02-08 |  |  |  |  |  | Kevin | 6h |  |
| 25 | 3.2.2.3 | Oppdatere Wiki | manual | 1d | 2024-02-09 A | 2024-02-09 A |  | 100% |  |  |  | Kevin | 6h | 6h |

| ID | WBS | Task | Type | Duration | Start | Finish | Predecessors | Complete | Remaining | Total slack | Resources | Work | Actual work |
| --- | --- | --- | --- | --- | --- | --- | --- | --- | --- | --- | --- | --- | --- |
| 26 | 3.3 | **Vannbehandling** |  | 26d | 2024-01-26 A | 2024-03-01 |  | 32% | 17.79d | 0d |  | 112h | 31h |
| 27 | 3.3.1 | **Prosjektering** |  | 6d | 2024-01-26 A | 2024-02-02 A |  | 100% |  |  |  | 16h | 16h |
| 28 | 3.3.1.1 | Funksjonsbeskrivelse | manual | 3d | 2024-01-26 A | 2024-01-30 A |  | 100% |  |  | Kevin | 4h | 4h |
| 29 | 3.3.1.2 | RIV-tegning | manual | 2d | 2024-01-31 A | 2024-02-01 A | 28 | 100% |  |  | Kevin | 8h | 8h |
| 30 | 3.3.1.3 | Automatikkskjema | manual | 1d | 2024-02-02 A | 2024-02-02 A | 29 | 100% |  |  | Kevin | 4h | 4h |
| 31 | 3.3.2 | **Programmering** |  | 15d | 2024-02-05 A | 2024-02-23 | 27 | 22% | 11.67d | 0d |  | 78h | 15h |
| 32 | 3.3.2.1 | **Funksjonsblokk sirk.pumpe** |  | 2d | 2024-02-05 | 2024-02-06 |  |  |  | 0d |  | 12h |  |
| 33 | 3.3.2.1.1 | Research | manual | 1d | 2024-02-05 | 2024-02-05 |  |  |  |  | Kevin | 3h |  |
| 34 | 3.3.2.1.2 | Koding | manual | 1d | 2024-02-05 | 2024-02-05 |  |  |  |  | Kevin | 2h |  |
| 35 | 3.3.2.1.3 | Testing | manual | 1d | 2024-02-06 | 2024-02-06 |  |  |  |  | Kevin | 2h |  |
| 36 | 3.3.2.1.4 | Ferdigstillelse | manual | 1d | 2024-02-06 | 2024-02-06 |  |  |  |  | Kevin | 2h |  |
| 37 | 3.3.2.1.5 | Dokumentajson | manual | 1d | 2024-02-06 | 2024-02-06 |  |  |  |  | Kevin | 3h |  |
| 38 | 3.3.2.2 | **Funksjonsblokk shuntmotor** |  | 2d | 2024-02-08 A | 2024-02-09 A |  | 100% |  |  |  | 12h | 12h |
| 39 | 3.3.2.2.1 | Research | manual | 1d | 2024-02-08 A | 2024-02-08 A |  | 100% |  |  | Vegard | 3h | 3h |
| 40 | 3.3.2.2.2 | Koding | manual | 1d | 2024-02-08 A | 2024-02-08 A |  | 100% |  |  | Vegard | 2h | 2h |
| 41 | 3.3.2.2.3 | Testing | manual | 1d | 2024-02-09 A | 2024-02-09 A |  | 100% |  |  | Vegard | 2h | 2h |
| 42 | 3.3.2.2.4 | Ferdigstillelse | manual | 1d | 2024-02-09 A | 2024-02-09 A |  | 100% |  |  | Vegard | 2h | 2h |
| 43 | 3.3.2.2.5 | Dokumentajson | manual | 1d | 2024-02-09 A | 2024-02-09 A |  | 100% |  |  | Vegard | 3h | 3h |
| 44 | 3.3.2.3 | **Funksjonsblokk sensorer** |  | 2d | 2024-02-12 A | 2024-02-13 |  | 20% | 1.6d | 0d |  | 12h | 3h |
| 45 | 3.3.2.3.1 | Research | manual | 1d | 2024-02-12 A | 2024-02-12 A |  | 100% |  |  | Vegard | 3h | 3h |
| 46 | 3.3.2.3.2 | Koding | manual | 1d | 2024-02-12 | 2024-02-12 |  |  |  |  | Vegard | 2h |  |
| 47 | 3.3.2.3.3 | Testing | manual | 1d | 2024-02-12 | 2024-02-12 |  |  |  |  | Vegard | 2h |  |
| 48 | 3.3.2.3.4 | Ferdigstillelse | manual | 1d | 2024-02-13 | 2024-02-13 |  |  |  |  | Vegard | 2h |  |
| 49 | 3.3.2.3.5 | Dokumentajson | manual | 1d | 2024-02-13 | 2024-02-13 |  |  |  |  | Vegard | 3h |  |

| ID | WBS | Task | Type | Duration | Start | Finish | Predecessors | Complete | Remaining | Total slack | Resources | Work | Actual work |
| --- | --- | --- | --- | --- | --- | --- | --- | --- | --- | --- | --- | --- | --- |
| 50 | 3.3.2.4 | **Funksjonsblokk simulator** |  | 3d | 2024-02-14 | 2024-02-16 |  |  |  |  |  | 12h |  |
| 51 | 3.3.2.4.1 | Research | manual | 1d | 2024-02-14 | 2024-02-14 |  |  |  |  | Vegard | 3h |  |
| 52 | 3.3.2.4.2 | Koding | manual | 1d | 2024-02-14 | 2024-02-14 |  |  |  |  | Vegard | 2h |  |
| 53 | 3.3.2.4.3 | Testing | manual | 1d | 2024-02-14 | 2024-02-14 |  |  |  |  | Vegard | 2h |  |
| 54 | 3.3.2.4.4 | Ferdigstillelse | manual | 1d | 2024-02-16 | 2024-02-16 |  |  |  |  | Vegard | 2h |  |
| 55 | 3.3.2.4.5 | Dokumentajson | manual | 1d | 2024-02-16 | 2024-02-16 |  |  |  |  | Vegard | 3h |  |
| 56 | 3.3.2.5 | **Funksjonsblokk MQTT mot toppsystem** |  | 3d | 2024-02-19 | 2024-02-21 |  |  |  |  |  | 12h |  |
| 57 | 3.3.2.5.1 | Research | manual | 1d | 2024-02-19 | 2024-02-19 |  |  |  |  | Vegard | 3h |  |
| 58 | 3.3.2.5.2 | Koding | manual | 1d | 2024-02-19 | 2024-02-19 |  |  |  |  | Vegard | 2h |  |
| 59 | 3.3.2.5.3 | Testing | manual | 1d | 2024-02-19 | 2024-02-19 |  |  |  |  | Vegard | 2h |  |
| 60 | 3.3.2.5.4 | Ferdigstillelse | manual | 1d | 2024-02-21 | 2024-02-21 |  |  |  |  | Vegard | 2h |  |
| 61 | 3.3.2.5.5 | Dokumentajson | manual | 1d | 2024-02-21 | 2024-02-21 |  |  |  |  | Vegard | 3h |  |
| 62 | 3.3.2.6 | Offline testing mot simulator | manual | 1d | 2024-02-22 | 2024-02-22 | 56 |  |  |  | Vegard | 8h |  |
| 63 | 3.3.2.7 | Feilsøking | manual | 1d | 2024-02-23 | 2024-02-23 | 62 |  |  |  | Vegard | 10h |  |
| 64 | 3.3.3 | **Dokumentasjon** |  | 5d | 2024-02-26 | 2024-03-01 | 31 |  |  | 0d |  | 18h |  |
| 65 | 3.3.3.1 | Finne frem nødvendig datablad | manual | 2d | 2024-02-26 | 2024-02-27 |  |  |  |  | Vegard | 6h |  |
| 66 | 3.3.3.2 | Oppdatere rapport | manual | 2d | 2024-02-28 | 2024-02-29 | 65 |  |  |  | Vegard | 6h |  |
| 67 | 3.3.3.3 | Oppdatere Wiki | manual | 1d | 2024-03-01 | 2024-03-01 | 66 |  |  |  | Vegard | 6h |  |
| 68 | 3.4 | **Miljø og inneklima** |  | 26d | 2024-01-26 A | 2024-03-01 |  | 68% | 8.21d | 0d |  | 108h | 62h |
| 69 | 3.4.1 | **Prosjektering** |  | 6d | 2024-01-26 A | 2024-02-02 A |  | 100% |  |  |  | 14h | 14h |
| 70 | 3.4.1.1 | Funksjonsbeskrivelse | manual | 3d | 2024-01-26 A | 2024-01-30 A |  | 100% |  |  | Kevin | 4h | 4h |
| 71 | 3.4.1.2 | Prinsippskisse | manual | 2d | 2024-01-31 A | 2024-02-01 A | 70 | 100% |  |  | Kevin | 6h | 6h |
| 72 | 3.4.1.3 | Automatikkskjema | manual | 1d | 2024-02-02 A | 2024-02-02 A | 71 | 100% |  |  | Kevin | 4h | 4h |
| 73 | 3.4.2 | **Programmering** |  | 12d | 2024-02-08 A | 2024-02-23 | 72, 69 | 74% | 3.11d | 0d |  | 76h | 48h |
| 74 | 3.4.2.1 | **Funksjonsblokk temp.sensor** |  | 2d | 2024-02-08 A | 2024-02-09 A |  | 100% |  |  |  | 12h | 12h |
| 75 | 3.4.2.1.1 | Research | manual | 1d | 2024-02-08 A | 2024-02-08 A |  | 100% |  |  | Kevin | 3h | 3h |
| 76 | 3.4.2.1.2 | Koding | manual | 1d | 2024-02-08 A | 2024-02-08 A |  | 100% |  |  | Kevin | 2h | 2h |
| 77 | 3.4.2.1.3 | Testing | manual | 1d | 2024-02-09 A | 2024-02-09 A |  | 100% |  |  | Kevin | 2h | 2h |
| 78 | 3.4.2.1.4 | Ferdigstillelse | manual | 1d | 2024-02-09 A | 2024-02-09 A |  | 100% |  |  | Kevin | 2h | 2h |
| 79 | 3.4.2.1.5 | Dokumentajson | manual | 1d | 2024-02-09 A | 2024-02-09 A |  | 100% |  |  | Kevin | 3h | 3h |

| ID | WBS | Task | Type | Duration | Start | Finish | Predecessors | Complete | Resources | Work | Actual work |
| --- | --- | --- | --- | --- | --- | --- | --- | --- | --- | --- | --- |
| 80 | 3.4.2.2 | **Funksjonsblokk CO²-sesnor** |  | 2d | 2024-02-08 A | 2024-02-09 A |  | 100% |  | 12h | 12h |
| 81 | 3.4.2.2.1 | Research | manual | 1d | 2024-02-08 A | 2024-02-08 A |  | 100% | Joar | 3h | 3h |
| 82 | 3.4.2.2.2 | Koding | manual | 1d | 2024-02-08 A | 2024-02-08 A |  | 100% | Joar | 2h | 2h |
| 83 | 3.4.2.2.3 | Testing | manual | 1d | 2024-02-09 A | 2024-02-09 A |  | 100% | Joar | 2h | 2h |
| 84 | 3.4.2.2.4 | Ferdigstillelse | manual | 1d | 2024-02-09 A | 2024-02-09 A |  | 100% | Joar | 2h | 2h |
| 85 | 3.4.2.2.5 | Dokumentajson | manual | 1d | 2024-02-09 A | 2024-02-09 A |  | 100% | Joar | 3h | 3h |
| 86 | 3.4.2.3 | **Funksjonsblokk luftfuktighetssensor** |  | 2d | 2024-02-12 A | 2024-02-13 A |  | 100% |  | 12h | 12h |
| 87 | 3.4.2.3.1 | Research | manual | 1d | 2024-02-12 A | 2024-02-12 A |  | 100% | Joar | 3h | 3h |
| 88 | 3.4.2.3.2 | Koding | manual | 1d | 2024-02-12 A | 2024-02-12 A |  | 100% | Joar | 2h | 2h |
| 89 | 3.4.2.3.3 | Testing | manual | 1d | 2024-02-12 A | 2024-02-12 A |  | 100% | Joar | 2h | 2h |
| 90 | 3.4.2.3.4 | Ferdigstillelse | manual | 1d | 2024-02-13 A | 2024-02-13 A |  | 100% | Joar | 2h | 2h |
| 91 | 3.4.2.3.5 | Dokumentajson | manual | 1d | 2024-02-13 A | 2024-02-13 A |  | 100% | Joar | 3h | 3h |
| 92 | 3.4.2.4 | **Funksjonsblokk simulator** |  | 3d | 2024-02-14 A | 2024-02-16 A |  | 100% |  | 12h | 12h |
| 93 | 3.4.2.4.1 | Research | manual | 1d | 2024-02-14 A | 2024-02-14 A |  | 100% | Joar | 3h | 3h |
| 94 | 3.4.2.4.2 | Koding | manual | 1d | 2024-02-14 A | 2024-02-14 A |  | 100% | Joar | 2h | 2h |
| 95 | 3.4.2.4.3 | Testing | manual | 1d | 2024-02-14 A | 2024-02-14 A |  | 100% | Joar | 2h | 2h |
| 96 | 3.4.2.4.4 | Ferdigstillelse | manual | 1d | 2024-02-16 A | 2024-02-16 A |  | 100% | Joar | 2h | 2h |
| 97 | 3.4.2.4.5 | Dokumentajson | manual | 1d | 2024-02-16 A | 2024-02-16 A |  | 100% | Joar | 3h | 3h |
| 98 | 3.4.2.5 | **Funksjonsblokk MQTT mot toppsystem** |  | 3d | 2024-02-19 | 2024-02-21 |  |  |  | 12h |  |
| 99 | 3.4.2.5.1 | Research | manual | 1d | 2024-02-19 | 2024-02-19 |  |  | Joar | 3h |  |
| 100 | 3.4.2.5.2 | Koding | manual | 1d | 2024-02-19 | 2024-02-19 |  |  | Joar | 2h |  |
| 101 | 3.4.2.5.3 | Testing | manual | 1d | 2024-02-19 | 2024-02-19 |  |  | Joar | 2h |  |
| 102 | 3.4.2.5.4 | Ferdigstillelse | manual | 1d | 2024-02-21 | 2024-02-21 |  |  | Joar | 2h |  |
| 103 | 3.4.2.5.5 | Dokumentajson | manual | 1d | 2024-02-21 | 2024-02-21 |  |  | Joar | 3h |  |
| 104 | 3.4.2.6 | Offline testing mot simulator | manual | 1d | 2024-02-22 | 2024-02-22 | 98 |  | Joar | 8h |  |
| 105 | 3.4.2.7 | Feilsøking | manual | 1d | 2024-02-23 | 2024-02-23 | 104 |  | Joar | 8h |  |

| ID | WBS | Task | Type | Duration | Start | Finish | Predecessors | Complete | Remaining | Total slack | Resources | Work | Actual work |
| --- | --- | --- | --- | --- | --- | --- | --- | --- | --- | --- | --- | --- | --- |
| 106 | 3.4.3 | **Dokumetnasjon** |  | 5d | 2024-02-26 | 2024-03-01 | 73 |  |  | 0d |  | 18h |  |
| 107 | 3.4.3.1 | Finne frem nødvendig datablad | manual | 2d | 2024-02-26 | 2024-02-27 |  |  |  |  | Joar | 6h |  |
| 108 | 3.4.3.2 | Oppdatere rapport | manual | 2d | 2024-02-28 | 2024-02-29 | 107 |  |  |  | Joar | 6h |  |
| 109 | 3.4.3.3 | Oppdatere Wiki | manual | 1d | 2024-03-01 | 2024-03-01 | 108 |  |  |  | Joar | 6h |  |
| 110 | 3.5 | **SD-anlegg/GUI** |  | 26d | 2024-01-26 A | 2024-03-01 |  | 35% | 16.96d | 0d |  | 86h | 16h |
| 111 | 3.5.1 | **Prosjektering** |  | 3d | 2024-01-26 A | 2024-01-30 A |  | 100% |  |  |  | 4h | 4h |
| 112 | 3.5.1.1 | Funksjonsbeskrivelse | manual | 3d | 2024-01-26 A | 2024-01-30 A |  | 100% |  |  | Kevin | 4h | 4h |
| 113 | 3.5.2 | **Programmering** |  | 15d | 2024-02-05 A | 2024-02-23 | 111 | 33% | 10d | 0d |  | 54h | 12h |
| 114 | 3.5.2.1 | Research CDP | manual | 5d | 2024-02-05 A | 2024-02-09 A |  | 100% |  |  | Peter | 12h | 12h |
| 115 | 3.5.2.2 | Grafisk design | manual | 3d | 2024-02-12 | 2024-02-14 | 114 |  |  |  | Peter | 8h |  |
| 116 | 3.5.2.3 | Funksjon ta imot MQTT fra vannbehandling | manual | 2d | 2024-02-15 | 2024-02-16 |  |  |  |  | Peter | 8h |  |
| 117 | 3.5.2.4 | Funksjon ta imot MQTT fra Miljø og Inneklima | manual | 2d | 2024-02-19 | 2024-02-20 |  |  |  |  | Peter | 8h |  |
| 118 | 3.5.2.5 | Offline testing | manual | 1d | 2024-02-21 | 2024-02-21 | 117 |  |  |  | Peter | 10h |  |
| 119 | 3.5.2.6 | Feilsøking | manual | 2d | 2024-02-22 | 2024-02-23 | 118 |  |  |  | Peter | 8h |  |
| 120 | 3.5.3 | **Dokumentasjon** |  | 5d | 2024-02-26 | 2024-03-01 | 113 |  |  | 0d |  | 28h |  |
| 121 | 3.5.3.1 | Finne frem nødvendig datablad | manual | 2d | 2024-02-26 | 2024-02-27 |  |  |  |  | Kevin | 16h |  |
| 122 | 3.5.3.2 | Oppdatere rapport | manual | 2d | 2024-02-28 | 2024-02-29 | 121 |  |  |  | Peter | 6h |  |
| 123 | 3.5.3.3 | Oppdatere Wiki | manual | 1d | 2024-03-01 | 2024-03-01 | 122 |  |  |  | Peter | 6h |  |
| 124 | 4 | Prosjekteringsfase fullført | milestone | 0d | 2024-03-01 | 2024-03-01 | 13 |  |  | 0d |  |  |  |
| 125 | 5 | **Gjennomføringsfasen** |  | 15d | 2024-03-04 | 2024-03-22 | 124 |  |  | 0d |  | 148h |  |
| 126 | 5.1 | **Administrativt** |  | 5d | 2024-03-04 | 2024-03-08 |  |  |  | 0d |  | 8h |  |
| 127 | 5.1.1 | **Testprotokoller** |  | 5d | 2024-03-04 | 2024-03-08 |  |  |  | 0d |  | 8h |  |
| 128 | 5.1.1.1 | Opprette mal for testprotokoller | manual | 5d | 2024-03-04 | 2024-03-08 |  |  |  |  | Kevin | 8h |  |
| 129 | 5.2 | **Bygg** |  | 10d | 2024-03-04 | 2024-03-15 |  |  |  | 0d |  | 24h |  |
| 130 | 5.2.1 | **Konstruksjon** |  | 5d | 2024-03-04 | 2024-03-08 |  |  |  | 0d |  | 12h |  |
| 131 | 5.2.1.1 | Montasje av utstyr på eksisterende konstruksjon | manual | 5d | 2024-03-04 | 2024-03-08 |  |  |  |  | Peter | 12h |  |

| ID | WBS | Task | Type | Duration | Start | Finish | Predecessors | Total slack | Resources | Work |
| --- | --- | --- | --- | --- | --- | --- | --- | --- | --- | --- |
| 132 | 5.2.2 | **Dokumentasjon** |  | 5d | 2024-03-11 | 2024-03-15 | 130 | 0d |  | 12h |
| 133 | 5.2.2.1 | Finne frem nødvendig datablad | manual | 2d | 2024-03-11 | 2024-03-12 |  |  | Peter | 4h |
| 134 | 5.2.2.2 | Oppdatere rapport | manual | 2d | 2024-03-13 | 2024-03-14 |  |  | Peter | 4h |
| 135 | 5.2.2.3 | Oppdatere Wiki | manual | 1d | 2024-03-15 | 2024-03-15 |  |  | Peter | 4h |
| 136 | 5.3 | **Vannbehandling** |  | 15d | 2024-03-04 | 2024-03-22 |  | 0d |  | 46h |
| 137 | 5.3.1 | **Automatikkstyring** |  | 2d | 2024-03-04 | 2024-03-05 |  | 0d |  | 6h |
| 138 | 5.3.1.1 | Koble automatikkstyring | manual | 2d | 2024-03-04 | 2024-03-05 |  |  | Vegard | 6h |
| 139 | 5.3.2 | **Montasje** |  | 3d | 2024-03-06 | 2024-03-08 | 137 | 0d |  | 10h |
| 140 | 5.3.2.1 | Montering av utstyr og automatikk | manual | 3d | 2024-03-06 | 2024-03-08 |  |  | Vegard | 10h |
| 141 | 5.3.3 | **Funksjonstesting** |  | 5d | 2024-03-11 | 2024-03-15 | 139 | 0d |  | 12h |
| 142 | 5.3.3.1 | Integrert test for systemet | manual | 5d | 2024-03-11 | 2024-03-15 |  |  | Vegard | 12h |
| 143 | 5.3.4 | **Dokumentasjon** |  | 5d | 2024-03-18 | 2024-03-22 | 141 | 0d |  | 18h |
| 144 | 5.3.4.1 | Finne frem nødvendig datablad | manual | 2d | 2024-03-18 | 2024-03-19 |  |  | Vegard | 6h |
| 145 | 5.3.4.2 | Oppdatere rapport | manual | 2d | 2024-03-20 | 2024-03-21 | 144 |  | Vegard | 6h |
| 146 | 5.3.4.3 | Oppdatere Wiki | manual | 1d | 2024-03-22 | 2024-03-22 | 145 |  | Vegard | 6h |
| 147 | 5.4 | **Miljø og Inneklima** |  | 15d | 2024-03-04 | 2024-03-22 |  | 0d |  | 46h |
| 148 | 5.4.1 | **Automatikkstyring** |  | 2d | 2024-03-04 | 2024-03-05 |  | 0d |  | 6h |
| 149 | 5.4.1.1 | Koble automatikkstyring | manual | 2d | 2024-03-04 | 2024-03-05 |  |  | Joar | 6h |
| 150 | 5.4.2 | **Montasje** |  | 3d | 2024-03-06 | 2024-03-08 | 130, 148 | 0d |  | 10h |
| 151 | 5.4.2.1 | Montering av utstyr og automatikk | manual | 3d | 2024-03-06 | 2024-03-08 |  |  | Joar | 10h |
| 152 | 5.4.3 | **Funksjonstesting** |  | 5d | 2024-03-11 | 2024-03-15 | 150 | 0d |  | 12h |
| 153 | 5.4.3.1 | Integrert test for systemet | manual | 5d | 2024-03-11 | 2024-03-15 |  |  | Joar | 12h |
| 154 | 5.4.4 | **Dokumentasjon** |  | 5d | 2024-03-18 | 2024-03-22 | 152 | 0d |  | 18h |
| 155 | 5.4.4.1 | Finne frem nødvendig datablad | manual | 2d | 2024-03-18 | 2024-03-19 |  |  | Joar | 6h |
| 156 | 5.4.4.2 | Oppdatere rapport | manual | 2d | 2024-03-20 | 2024-03-21 | 155 |  | Joar | 6h |
| 157 | 5.4.4.3 | Oppdatere Wiki | manual | 1d | 2024-03-22 | 2024-03-22 | 156 |  | Joar | 6h |

| ID | WBS | Task | Type | Duration | Start | Finish | Predecessors | Total slack | Resources | Work |
| --- | --- | --- | --- | --- | --- | --- | --- | --- | --- | --- |
| 158 | 5.5 | **SD-anlegg/GUI** |  | 10d | 2024-03-11 | 2024-03-22 |  | 0d |  | 24h |
| 159 | 5.5.1 | **Funksjonstesting** |  | 5d | 2024-03-11 | 2024-03-15 |  | 0d |  | 12h |
| 160 | 5.5.1.1 | Integrert test for systemet | manual | 5d | 2024-03-11 | 2024-03-15 |  |  | Peter | 12h |
| 161 | 5.5.2 | **Dokumentasjon** |  | 5d | 2024-03-18 | 2024-03-22 | 159 | 0d |  | 12h |
| 162 | 5.5.2.1 | Finne frem nødvendig datablad | manual | 2d | 2024-03-18 | 2024-03-19 |  |  | Peter | 4h |
| 163 | 5.5.2.2 | Oppdatere rapport | manual | 2d | 2024-03-20 | 2024-03-21 | 162 |  | Peter | 4h |
| 164 | 5.5.2.3 | Oppdatere Wiki | manual | 1d | 2024-03-22 | 2024-03-22 | 163 |  | Peter | 4h |
| 165 | 6 | Gjennomføringsfase fullført | milestone | 0d | 2024-03-22 | 2024-03-22 | 125 | 6d |  |  |
| 166 | 7 | **Testfasen** |  | 9d | 2024-04-02 | 2024-04-12 | 165 | 0d |  | 88h |
| 167 | 7.1 | **FST (Fullskalatest)** |  | 4d | 2024-04-02 | 2024-04-05 |  | 0d |  | 64h |
| 168 | 7.1.1 | FST (Fullskalatest) | manual | 2d | 2024-04-02 | 2024-04-03 |  |  | Joar; Kevin; Peter; Vegard | 32h |
| 169 | 7.1.2 | Feilsøking | manual | 2d | 2024-04-04 | 2024-04-05 | 168 |  | Joar; Kevin; Peter; Vegard | 32h |
| 170 | 7.2 | **Dokumentasjon** |  | 5d | 2024-04-08 | 2024-04-12 |  | 0d |  | 24h |
| 171 | 7.2.1 | Fylle ut testprotokoller | manual | 2d | 2024-04-08 | 2024-04-09 |  |  | Joar; Kevin; Peter; Vegard | 8h |
| 172 | 7.2.2 | Oppdatere rapport | manual | 2d | 2024-04-10 | 2024-04-11 |  |  | Joar; Kevin; Peter; Vegard | 8h |
| 173 | 7.2.3 | Oppdatere Wiki | manual | 1d | 2024-04-12 | 2024-04-12 |  |  | Joar; Kevin; Peter; Vegard | 8h |
| 174 | 8 | Testfase fullført | milestone | 0d | 2024-04-12 | 2024-04-12 | 166 | 0d |  |  |
| 175 | 9 | **Avsluttningsfase** |  | 12d | 2024-04-15 | 2024-04-30 | 174 | 0d |  | 84h |
| 176 | 9.1 | Rapportskriving | manual | 10d | 2024-04-15 | 2024-04-26 |  |  | Joar; Kevin; Peter; Vegard | 60h |
| 177 | 9.2 | Wiki | manual | 2d | 2024-04-29 | 2024-04-30 |  |  | Joar; Kevin; Peter; Vegard | 24h |
| 178 | 10 | Avsluttningsfase fullført | milestone | 0d | 2024-04-30 | 2024-04-30 | 175 | 0d |  |  |
